# Factory Facelift #2

Schedule from MS Project, 2004-06-16 to 2004-07-09, costs in $.

## Calendars

- Standard: Mon-Fri 08:30-12:30, 13:00-17:00; Sat-Sun off.

## Resources

| Resource | Group | Unit | Rate | Cost per use |
| --- | --- | --- | --- | --- |
| Whelan Wreckers | Construction |  | 80 |  |
| B & G Construction | Construction |  | 45 |  |
| Empire Glasswork | Glasswork |  |  | 1800 |
| Paula's Gardening | Gardening |  | 30 |  |
| Barnett Plumbing | Construction |  | 80 |  |
| Marty Martin | Proj. Admin. |  | 45 |  |
| Paint |  | Gallons | 17.5 |  |

## Schedule

| ID | WBS | Task | Type | Duration | Start | Finish | Predecessors | Total slack | Free slack | Constraint | Resources | Work | Cost |
| --- | --- | --- | --- | --- | --- | --- | --- | --- | --- | --- | --- | --- | --- |
| 1 | 1 | **Factory Facelift** |  | 17.5d | 2004-06-16 | 2004-07-09 |  | 0d |  |  | Marty Martin | 383h | 19,109.5 |
| 2 | 1.1 | **Build Façade** |  | 7.06d | 2004-06-16 | 2004-06-25 |  | 1.38d |  |  |  | 136h | 8,907 |
| 3 | 1.1.1 | Remove old exterior |  | 2d | 2004-06-16 | 2004-06-17 |  | 1.5d | 0.12d |  | Whelan Wreckers [200%] | 32h | 2,560 |
| 4 | 1.1.2 | Erect framework |  | 3d | 2004-06-17 | 2004-06-21 | 3 | 1.12d | 0d |  | B & G Construction [300%] | 72h | 2,880 |
| 5 | 1.1.3 | Add glasswork |  | 2d | 2004-06-21 | 2004-06-23 | 4 | 1.12d | 0d |  | Empire Glasswork | 16h | 1,800 |
| 6 | 1.1.4 | Erect/paint new walls |  | 2d | 2004-06-23 | 2004-06-25 | 5 | 1.12d | 0.94d |  | B & G Construction; Paint [50 Gallons] | 16h | 1,667 |
| 7 | 1.2 | **Landscape Garden** |  | 8d | 2004-06-28 | 2004-07-07 |  | 0d |  |  |  | 84h | 2,520 |
| 8 | 1.2.1 | Clear debris |  | 1d | 2004-06-28 | 2004-06-28 | 6 | 0.31d | 0d |  | Paula's Gardening | 8h | 240 |
| 9 | 1.2.2 | Add topsoil |  | 1d | 2004-06-28 | 2004-06-29 | 8 | 0.31d | 0d |  | Paula's Gardening | 8h | 240 |
| 10 | 1.2.3 | Lay lawns |  | 2d | 2004-06-29 | 2004-07-01 | 9 | 0.31d |  |  | Paula's Gardening | 16h | 480 |
| 11 | 1.2.4 | Plant trees and flower beds |  | 3.25d | 2004-07-05 | 2004-07-07 | 10 | 0d |  | start no earlier than 2004-07-02 | Paula's Gardening [200%] | 52h | 1,560 |
| 12 | 1.3 | **Erect Fountain** |  | 1.19d | 2004-07-07 | 2004-07-09 |  | 0d |  |  |  | 20h | 1,234 |
| 13 | 1.3.1 | Assemble fountain |  | 12h | 2004-07-07 | 2004-07-08 | 11 | 0d |  |  | B & G Construction | 12h | 594 |
| 14 | 1.3.2 | Connect plumbing |  | 4h | 2004-07-08 | 2004-07-09 | 13 | 0d |  |  | Barnett Plumbing [200%] | 8h | 640 |
| 15 | 1.4 | **Erect Flagpole** |  | 0.31d | 2004-07-09 | 2004-07-09 |  | 0d |  |  |  | 3h | 148.5 |
| 16 | 1.4.1 | Construct footing |  | 2h | 2004-07-09 | 2004-07-09 | 14 | 0d |  |  | B & G Construction | 2h | 99 |
| 17 | 1.4.2 | Attach flagpole |  | 1h | 2004-07-09 | 2004-07-09 | 16 | 0d |  |  | B & G Construction | 1h | 49.5 |
| 18 | 1.5 | Project Completed | milestone | 0d | 2004-07-09 | 2004-07-09 | 17 | 0d |  |  |  |  |  |
