# Factory Facelift #4

Schedule from MS Project, 2004-06-18 to 2004-07-13, status date 2003-07-07, costs in $, A marks actual dates.

## Calendars

- Standard: Mon-Fri 08:30-12:30, 13:00-17:00; Sat-Sun off.

## Resources

| Resource | Group | Unit | Rate | Cost per use |
| --- | --- | --- | --- | --- |
| Whelan Wreckers | Construction |  | 80 |  |
| B & G Construction | Construction |  | 45 |  |
| Empire Glasswork | Glasswork |  |  | 1800 |
| Paula's Gardening | Gardening |  | 30 |  |
| Barnett Plumbing | Construction |  | 80 |  |
| Marty Martin | Proj. Admin. |  | 45 |  |
| Paint |  | Gallons | 17.5 |  |

## Schedule

| ID | WBS | Task | Type | Duration | Start | Finish | Predecessors | Complete | Remaining | Baseline start | Baseline finish | Baseline duration | Total slack | Constraint | Resources | Work | Actual work | Cost | Baseline cost | Actual cost |
| --- | --- | --- | --- | --- | --- | --- | --- | --- | --- | --- | --- | --- | --- | --- | --- | --- | --- | --- | --- | --- |
| 1 | 1 | **Factory Facelift** |  | 17.44d | 2004-06-18 A | 2004-07-13 |  | 93% | 1.3d | 2003-06-16 | 2003-07-09 | 16.81d | 0d |  | Marty Martin | 394.5h | 367.06h | 18,860.87 | 18,670 | 17,283.57 |
| 2 | 1.1 | **Build Façade** |  | 7.5d | 2004-06-18 A | 2004-06-29 A |  | 100% |  | 2003-06-16 | 2003-06-25 | 7.06d |  |  |  | 160h | 160h | 8,996.87 | 8,835 | 8,996.87 |
| 3 | 1.1.1 | Remove old exterior |  | 2d | 2004-06-18 A | 2004-06-21 A |  | 100% |  | 2003-06-16 | 2003-06-17 | 2d |  |  | Whelan Wreckers [200%] | 32h | 32h | 2,560 | 2,560 | 2,560 |
| 4 | 1.1.2 | Erect framework |  | 4d | 2004-06-19 A | 2004-06-23 A | 3 | 100% |  | 2003-06-17 | 2003-06-19 | 3d |  |  | B & G Construction [300%] | 96h | 96h | 3,840 | 2,880 | 3,840 |
| 5 | 1.1.3 | Add glasswork |  | 2d | 2004-06-24 A | 2004-06-25 A | 4 | 100% |  | 2003-06-19 | 2003-06-23 | 2d |  |  | Empire Glasswork | 16h | 16h | 1,800 | 1,800 | 1,800 |
| 6 | 1.1.4 | Erect/paint new walls |  | 2d | 2004-06-26 A | 2004-06-29 A | 5 | 100% |  | 2003-06-23 | 2003-06-25 | 2d |  |  | B & G Construction; Paint [0.28 Gallons] | 16h | 16h | 796.87 | 1,595 | 796.87 |
| 7 | 1.2 | **Landscape Garden** |  | 5.19d | 2004-06-30 A | 2004-07-07 A |  | 100% |  | 2003-06-25 | 2003-07-07 | 8.19d |  |  |  | 72h | 72h | 2,160 | 2,400 | 2,160 |
| 8 | 1.2.1 | Clear debris |  | 1d | 2004-06-30 A | 2004-06-30 A | 6 | 100% |  | 2003-06-25 | 2003-06-25 | 1d |  |  | Paula's Gardening | 8h | 8h | 240 | 240 | 240 |
| 9 | 1.2.2 | Add topsoil |  | 1d | 2004-06-30 A | 2004-06-30 A | 8 | 100% |  | 2003-06-26 | 2003-06-26 | 1d |  |  | Paula's Gardening | 8h | 8h | 240 | 240 | 240 |
| 10 | 1.2.3 | Lay lawns |  | 2d | 2004-07-01 A | 2004-07-05 A | 9 | 100% |  | 2003-06-26 | 2003-07-01 | 2d |  |  | Paula's Gardening | 16h | 16h | 480 | 480 | 480 |
| 11 | 1.2.4 | Plant trees and flower beds |  | 2.5d | 2004-07-03 A | 2004-07-07 A | 10 | 100% |  | 2003-07-02 | 2003-07-07 | 3d |  | start no earlier than 2003-07-02 | Paula's Gardening [200%] | 40h | 40h | 1,200 | 1,440 | 1,200 |
| 12 | 1.3 | **Erect Fountain** |  | 1.06d | 2004-07-10 A | 2004-07-13 |  | 33% | 0.71d | 2003-07-07 | 2003-07-09 | 1.25d | 0d |  |  | 20h | 6h | 1,278 | 1,234 | 319 |
| 13 | 1.3.1 | Assemble fountain |  | 8h | 2004-07-10 A | 2004-07-12 | 11 | 50% | 4h | 2003-07-07 | 2003-07-08 | 12h | 0d | finish no earlier than 2004-07-12 | B & G Construction | 12h | 6h | 638 | 594 | 319 |
| 14 | 1.3.2 | Connect plumbing |  | 4h | 2004-07-12 | 2004-07-13 | 13 |  |  | 2003-07-08 | 2003-07-09 | 4h | 0d |  | Barnett Plumbing [200%] | 8h |  | 640 | 640 |  |
| 15 | 1.4 | **Erect Flagpole** |  | 0.38d | 2004-07-13 | 2004-07-13 |  |  |  | 2003-07-09 | 2003-07-09 | 0.31d | 0d |  |  | 3h |  | 148.5 | 148.5 |  |
| 16 | 1.4.1 | Construct footing |  | 2h | 2004-07-13 | 2004-07-13 | 14 |  |  | 2003-07-09 | 2003-07-09 | 2h | 0d |  | B & G Construction | 2h |  | 99 | 99 |  |
| 17 | 1.4.2 | Attach flagpole |  | 1h | 2004-07-13 | 2004-07-13 | 16 |  |  | 2003-07-09 | 2003-07-09 | 1h | 0d |  | B & G Construction | 1h |  | 49.5 | 49.5 |  |
| 18 | 1.5 | Project Completed | milestone | 0d | 2004-07-13 | 2004-07-13 | 17 |  |  | 2003-07-09 | 2003-07-09 | 0d | 0d |  |  |  |  |  |  |  |
