# Pamphlet Ad #3

Schedule from MS Project, 2004-03-10 to 2004-03-21, costs in $.

## Calendars

- Standard: Mon-Fri 08:00-12:00, 13:00-17:00; Sat-Sun off.

## Resources

| Resource | Group | Rate | Cost per use |
| --- | --- | --- | --- |
| Perfect Printing | Printing |  | 4500 |
| SF Couriers | Delivery |  | 30 |
| Peter Allcot | Marketing | 25 |  |
| Julie Winters | Marketing | 25 |  |
| Distributors |  | 12.5 |  |

## Schedule

| ID | WBS | Task | Type | Duration | Start | Finish | Predecessors | Total slack | Free slack | Constraint | Deadline | Resources | Work | Cost |
| --- | --- | --- | --- | --- | --- | --- | --- | --- | --- | --- | --- | --- | --- | --- |
| 1 | 1 | **Pamphlet Advertising** |  | 8d | 2004-03-10 | 2004-03-21 |  | 0d |  |  |  |  | 82h | 5,505 |
| 2 | 1.1 | **Printing of pamphlets** |  | 4.5d | 2004-03-10 | 2004-03-16 |  | 1.5d | 0d |  |  |  | 36h | 4,730 |
| 3 | 1.1.1 | Design pamphlet |  | 1d | 2004-03-10 | 2004-03-10 |  | 1.5d | 0d |  |  | Julie Winters | 8h | 200 |
| 4 | 1.1.2 | Deliver design to printers |  | 0.5d | 2004-03-11 | 2004-03-11 | 3 | 1.5d | 0d |  |  | SF Couriers | 4h | 30 |
| 5 | 1.1.3 | Print pamphlets |  | 3d | 2004-03-11 | 2004-03-16 | 4 | 1.5d | 0d |  |  | Perfect Printing | 24h | 4,500 |
| 6 | 1.1.4 | Pamphlets received by us | milestone | 0d | 2004-03-16 | 2004-03-16 | 5 | 1.5d |  |  |  |  |  |  |
| 7 | 1.2 | **Distribution of pamphlets** |  | 3.5d | 2004-03-16 | 2004-03-21 | 2 | 0d |  |  |  |  | 46h | 775 |
| 8 | 1.2.1 | Pick up pamphlets |  | 1d | 2004-03-16 | 2004-03-17 |  | 1.5d | 0d |  |  | Peter Allcot | 8h | 200 |
| 9 | 1.2.2 | Deliver pamphlets to distributors |  | 1d | 2004-03-17 | 2004-03-18 | 8 | 1.5d |  |  | 2004-03-21 | Peter Allcot | 8h | 200 |
| 10 | 1.2.3 | Sunday delivery of pamphlets |  | 6h | 2004-03-21 | 2004-03-21 | 9 | 0d |  | must start on 2004-03-21 |  | Distributors [500%] | 30h | 375 |
