# Training Materials #2

Schedule from MS Project, 2004-07-05 to 2004-07-27, costs in $.

## Calendars

- Standard: Mon-Fri 08:30-12:00, 13:00-17:30; Sat-Sun off.

## Resources

| Resource | Group | Rate | Cost per use |
| --- | --- | --- | --- |
| Michael Mann | Development | 30 |  |
| Sally Sanders | Editing | 20 |  |
| Wendy Worth | Testing | 15 |  |
| Speedy Courier | Delivery |  | 25 |
| ABC Printers | Printing | 25 |  |

## Schedule

| ID | WBS | Task | Type | Duration | Start | Finish | Predecessors | Total slack | Constraint | Resources | Work | Cost |
| --- | --- | --- | --- | --- | --- | --- | --- | --- | --- | --- | --- | --- |
| 1 | 1 | **Develop Training Manual** |  | 12d | 2004-07-05 | 2004-07-20 |  | 0d |  |  | 104h | 2,760 |
| 2 | 1.1 | Write manual |  | 8d | 2004-07-05 | 2004-07-14 |  | 0d |  | Michael Mann | 64h | 1,920 |
| 3 | 1.2 | Create graphics |  | 1d | 2004-07-15 | 2004-07-15 | 2 | 0d |  | Michael Mann | 8h | 240 |
| 4 | 1.3 | Edit and proof manual |  | 2d | 2004-07-16 | 2004-07-19 | 3 | 0d |  | Sally Sanders | 16h | 320 |
| 5 | 1.4 | Test exercises |  | 1d | 2004-07-19 | 2004-07-19 | 4FS-1d | 0d |  | Wendy Worth | 8h | 120 |
| 6 | 1.5 | Re-edit manual |  | 1d | 2004-07-20 | 2004-07-20 | 5 | 0d |  | Sally Sanders | 8h | 160 |
| 7 | 1.6 | Manual completed | milestone | 0d | 2004-07-20 | 2004-07-20 | 6 | 0d |  |  |  |  |
| 8 | 2 | **Develop Instructor Guide** |  | 3d | 2004-07-21 | 2004-07-23 |  | 0d |  |  | 24h | 640 |
| 9 | 2.1 | Write guide |  | 2d | 2004-07-21 | 2004-07-22 | 7 | 0d | start no earlier than 2003-07-28 | Michael Mann | 16h | 480 |
| 10 | 2.2 | Edit and proof guide |  | 1d | 2004-07-23 | 2004-07-23 | 9 | 0d |  | Sally Sanders | 8h | 160 |
| 11 | 2.3 | Guide completed | milestone | 0d | 2004-07-23 | 2004-07-23 | 10 | 0d |  |  |  |  |
| 12 | 3 | **Print Materials** |  | 1.38d | 2004-07-26 | 2004-07-27 |  | 0d |  |  | 22h | 450 |
| 13 | 3.1 | Deliver masters to printer |  | 3h | 2004-07-26 | 2004-07-26 | 11 | 0d |  | Speedy Courier | 3h | 25 |
| 14 | 3.2 | Print manual and guide |  | 1d | 2004-07-26 | 2004-07-27 | 13 | 0d |  | ABC Printers [200%] | 16h | 400 |
| 15 | 3.3 | Deliver printed materials to us |  | 3h | 2004-07-27 | 2004-07-27 | 14 | 0d |  | Speedy Courier | 3h | 25 |
| 16 | 3.4 | Project completed | milestone | 0d | 2004-07-27 | 2004-07-27 | 15 | 0d |  |  |  |  |
